# 2016 winter shut down target hall schedule

Schedule from MS Project, 2016-02-11 to 2016-05-16, A marks actual dates.

## Calendars

- Standard: Mon-Fri 08:00-12:00, 13:00-17:00; Sat-Sun off.

## Resources

| Resource |
| --- |
| Wang.D |
| Cave.T |
| Fisher.C |
| McDonald.D |
| RPG |
| Jackson.D |
| Mjos.A |
| Minor.G |
| Paley.B |
| Vacuum Group |
| Plant Group |
| Target Group |

## Schedule

| ID | WBS | Task | Duration | Start | Finish | Predecessors | Complete | Total slack | Free slack | Constraint | Resources | Work | Actual work |
| --- | --- | --- | --- | --- | --- | --- | --- | --- | --- | --- | --- | --- | --- |
| 1 | 1 | **TM3 Service Chase and Containment box Field Check** | 2d | 2016-02-15 08:00 A | 2016-02-16 17:00 A |  | 100% |  |  |  |  | 48h | 48h |
| 2 | 1.1 | TM3 Service Chase and Containment box Field Check | 2d | 2016-02-15 08:00 A | 2016-02-16 17:00 A |  | 100% |  |  | start no earlier than 2016-02-15 08:00 | Target Group; RPG; Wang.D | 48h | 48h |
| 3 | 2 | **TARGET HALL WATER SYSTEM UPGRADE** | 5d | 2016-02-17 08:00 A | 2016-02-23 17:00 A |  | 100% |  |  |  |  | 40h | 40h |
| 4 | 2.1 | Shielding Blocks Move for Work Area Accessing | 1d | 2016-02-17 08:00 A | 2016-02-17 17:00 A |  | 100% |  |  | finish no earlier than 2016-02-17 17:00 | Wang.D; McDonald.D | 16h | 16h |
| 5 | 2.2 | Water Sytem Upgrade and Test | 3d | 2016-02-19 08:00 A | 2016-02-23 17:00 A | 4 | 100% |  |  | start no earlier than 2016-02-19 08:00 | Wang.D; Mjos.A; Plant Group | 24h | 24h |
| 6 | 3 | **Shut Down Leak Check - Target Stations and Modules** | 4d | 2016-02-24 08:00 A | 2016-02-29 17:00 A |  | 100% |  |  |  |  | 64h | 64h |
| 7 | 3.1 | Module Disconnection-TM2/ITW | 1d | 2016-02-26 08:00 A | 2016-02-26 17:00 A | 4 | 100% |  |  | start no earlier than 2016-02-26 08:00 | Wang.D; McDonald.D | 16h | 16h |
| 8 | 3.2 | ITW and TM2 Vacuum Leak Check | 1d | 2016-02-29 08:00 A | 2016-02-29 17:00 A | 7 | 100% |  |  | start no earlier than 2016-02-29 08:00 | Wang.D; McDonald.D | 16h | 16h |
| 9 | 3.3 | Shielding Blocks Move- ITE to Storage Area | 0.5d | 2016-02-24 08:00 A | 2016-02-24 12:00 A |  | 100% |  |  | start no earlier than 2016-02-24 08:00 | Wang.D; McDonald.D | 8h | 8h |
| 10 | 3.4 | Module Disconnection-TM4-ITE | 0.5d | 2016-02-24 13:00 A | 2016-02-24 17:00 A | 9 | 100% |  |  | start no earlier than 2016-02-16 08:00 | Wang.D; McDonald.D | 8h | 8h |
| 11 | 3.5 | ITE and TM4 Vacuum leak Check | 1d | 2016-02-25 08:00 A | 2016-02-25 17:00 A | 10 | 100% |  |  | start no earlier than 2016-02-17 08:00 | McDonald.D; Wang.D | 16h | 16h |
| 12 | 4 | **ISAC Spent targets Shipment** | 6d | 2016-02-11 08:00 A | 2016-02-18 17:00 A |  | 100% |  |  |  |  | 40h | 40h |
| 13 | 4.1 | F308s Move- Ante Room to Target Hall | 0.5d | 2016-02-11 08:00 A | 2016-02-11 12:00 A |  | 100% |  |  | start no earlier than 2016-02-11 08:00 | Cave.T; Wang.D | 8h | 8h |
| 14 | 4.2 | Working area Set up | 0.5d | 2016-02-11 13:00 A | 2016-02-11 17:00 A | 13 | 100% |  |  | start no earlier than 2016-02-11 08:00 | Cave.T; Wang.D | 8h | 8h |
| 15 | 4.3 | Speant Targets Transfer- Mini Storage to F308s | 0.5d | 2016-02-18 08:00 A | 2016-02-18 12:00 A | 14 | 100% |  |  | start no earlier than 2016-02-18 08:00 | Cave.T; RPG; Wang.D | 12h | 12h |
| 16 | 4.4 | F308s Move- Target Hall to Ante Room | 0.5d | 2016-02-18 13:00 A | 2016-02-18 17:00 A | 15 | 100% |  |  | start no earlier than 2016-02-18 08:00 | Wang.D; McDonald.D; Cave.T | 12h | 12h |
| 17 | 5 | ITH MP1 Replacement | 1d | 2016-03-10 08:00 | 2016-03-10 17:00 |  |  | 47d |  | start no earlier than 2016-03-10 08:00 | Vacuum Group; Wang.D | 16h |  |
| 18 | 6 | **TM2 with New Lp Ucx target to ITW** | 8d | 2016-03-15 08:00 | 2016-03-24 17:00 |  |  | 4.2d |  |  |  | 109.2h |  |
| 19 | 6.1 | Module Move -TM2- ITW to SHC | 0.2d | 2016-03-15 08:00 | 2016-03-15 09:36 |  |  | 42d | 0d | start no earlier than 2016-03-15 08:00 | Cave.T; Wang.D; McDonald.D | 4.8h |  |
| 20 | 6.2 | Electrical Check | 0.1d | 2016-03-15 09:36 | 2016-03-15 10:24 | 19 |  | 42d | 0d | start no earlier than 2016-03-14 08:00 | Cave.T; Wang.D | 1.6h |  |
| 21 | 6.3 | Contaiment Box Moved out | 0.7d | 2016-03-15 10:24 | 2016-03-15 17:00 | 20 |  | 42d | 0d | start no earlier than 2016-03-14 08:00 | Fisher.C | 5.6h |  |
| 22 | 6.4 | Leak Check - TM2 -SHC | 2d | 2016-03-16 08:00 | 2016-03-17 17:00 | 21 |  | 42d |  | start no earlier than 2016-03-15 08:00 | Fisher.C; Wang.D | 32h |  |
| 23 | 6.5 | Containment Box Re-installed | 0.5d | 2016-03-18 08:00 | 2016-03-18 12:00 |  |  | 1.2d | 0d | start no earlier than 2016-03-18 08:00 | Fisher.C | 4h |  |
| 24 | 6.6 | Target Removal and Electrical Check | 0.5d | 2016-03-18 13:00 | 2016-03-18 17:00 | 23 |  | 1.2d | 0d | start no earlier than 2016-03-17 08:00 | Fisher.C; Cave.T; Wang.D | 12h |  |
| 25 | 6.7 | NewLp Ucx inert into SHC | 0.2d | 2016-03-21 08:00 | 2016-03-21 09:36 | 24 |  | 1.2d | 0d | start no earlier than 2016-03-18 08:00 | Fisher.C; Mjos.A | 3.2h |  |
| 26 | 6.8 | New Lp UCx Installation | 0.2d | 2016-03-21 09:36 | 2016-03-21 11:12 | 25 |  | 1.2d | 0d | start no earlier than 2016-03-18 08:00 | Fisher.C | 1.6h |  |
| 27 | 6.9 | TM2 with New Target Leak and Electrical Check- SHC | 0.1d | 2016-03-21 11:12 | 2016-03-21 12:00 | 26 |  | 1.2d | 0d | start no earlier than 2016-03-18 08:00 | Fisher.C; Cave.T; Wang.D | 2.4h |  |
| 28 | 6.10 | Module Move -TM2-SHC to TCS | 0.2d | 2016-03-21 13:00 | 2016-03-21 14:36 | 27 |  | 1.2d | 0d | start no earlier than 2016-03-04 08:00 | Wang.D; Cave.T | 3.2h |  |
| 29 | 6.11 | Module Connection- TM2 -TCS/Start of Pumps | 0.1d | 2016-03-21 14:36 | 2016-03-21 15:24 | 28 |  | 1.2d | 0.2d | start no earlier than 2016-03-04 08:00 | Wang.D | 0.8h |  |
| 30 | 6.12 | Spent Target Move | 1d | 2016-03-22 08:00 | 2016-03-22 17:00 | 29 |  | 1d |  | start no earlier than 2016-03-22 08:00 | Cave.T; Fisher.C; Wang.D | 24h |  |
| 31 | 6.13 | Module Disconnection-TM2-TCS | 0.25d | 2016-03-24 08:00 | 2016-03-24 10:00 | 30 |  | 0d |  | start no earlier than 2016-03-24 08:00 | Wang.D | 2h |  |
| 32 | 6.14 | Module Move-TM2- TCS to ITE | 0.25d | 2016-03-24 10:00 | 2016-03-24 12:00 | 31 |  | 0d |  | start no earlier than 2016-03-17 08:00 | Wang.D; Cave.T | 4h |  |
| 33 | 6.15 | Module Connection-TM2-ITW/ Start of Pumps | 0.5d | 2016-03-24 13:00 | 2016-03-24 17:00 | 32 |  | 0d |  | start no earlier than 2016-03-11 08:00 | McDonald.D; Wang.D | 8h |  |

| ID | WBS | Task | Duration | Start | Finish | Predecessors | Total slack | Constraint | Resources | Work |
| --- | --- | --- | --- | --- | --- | --- | --- | --- | --- | --- |
| 34 | 7 | **TM4 with New Lp Ta Target to ITE** | 4d | 2016-03-25 08:00 | 2016-03-30 17:00 |  | 0d |  |  | 72h |
| 35 | 7.1 | New Lp Ta Target Insert into SHC | 0.1d | 2016-03-25 08:00 | 2016-03-25 08:48 | 33 | 0d | start no earlier than 2016-03-24 08:00 | Fisher.C; Mjos.A | 1.6h |
| 36 | 7.2 | Module Move -TM4-ITE to SHC | 0.3d | 2016-03-25 08:48 | 2016-03-25 11:12 | 35 | 0d | start no earlier than 2016-03-16 08:00 | Cave.T; Wang.D | 4.8h |
| 37 | 7.3 | Target Removal and Electrical Check | 0.2d | 2016-03-25 11:12 | 2016-03-25 13:48 | 36 | 0d | start no earlier than 2016-03-16 08:00 | Wang.D; Cave.T | 3.2h |
| 38 | 7.4 | New Target Installation | 0.2d | 2016-03-25 13:48 | 2016-03-25 15:24 | 37 | 0d | start no earlier than 2016-03-16 08:00 | Fisher.C | 1.6h |
| 39 | 7.5 | Leak Check and Electrical Check | 0.2d | 2016-03-25 15:24 | 2016-03-25 17:00 | 38 | 0d | start no earlier than 2016-03-16 08:00 | Fisher.C; Cave.T; Wang.D | 4.8h |
| 40 | 7.6 | Module Move -TM4-SHC to ITE | 0.5d | 2016-03-28 08:00 | 2016-03-28 12:00 | 39 | 0d | start no earlier than 2016-03-17 08:00 | Cave.T; Wang.D | 8h |
| 41 | 7.7 | Module Connection- TM4 -ITW/ Start of Pumps | 0.5d | 2016-03-28 13:00 | 2016-03-28 17:00 | 40 | 0d | start no earlier than 2016-03-09 08:00 | Wang.D; McDonald.D | 8h |
| 42 | 7.8 | Target Inspection | 1d | 2016-03-29 08:00 | 2016-03-29 17:00 | 41 | 0d | start no earlier than 2016-03-18 08:00 | Fisher.C; Mjos.A | 16h |
| 43 | 7.9 | Spent Target Move | 1d | 2016-03-30 08:00 | 2016-03-30 17:00 | 42 | 0d | start no earlier than 2016-03-21 08:00 | Cave.T; Fisher.C; Wang.D | 24h |
| 44 | 8 | TM3 Refurbishment | 33d | 2016-03-31 08:00 | 2016-05-16 17:00 | 43 | 0d | finish no earlier than 2016-05-16 17:00 | Target Group; Cave.T; Fisher.C; Wang.D | 1056h |
